# QUEBRADAS CAÑETE-2024

Schedule from Primavera P6, 2024-06-01 to 2025-07-15, data date 2024-06-01, costs in PEN.
Must finish by 2025-07-15

## Calendars

- Huara III: Mon-Sun 07:30-16:30.

## Resources

| Resource | Group | Unit |
| --- | --- | --- |
| HH | labor |  |
| EXCAVADORA CAT 336 | equipment |  |
| Excavación de cimentacion | material |  |
| Relleno estructural | material |  |
| Colocación de roca recebada | material |  |
| Concreto premezclado F'C=280 kg/cm2 con cemento T-I | material |  |
| arena gruesa | material |  |
| Cemento Portlamd Tipo I | material |  |
| Acero Corrugado fy = 4200 kg/cm2 grado 60 | material |  |
| Geocompuesto de Drenaje | material |  |
| Baranda Metalica | material | m3 |
| Concreto premezclado F'C=100 kg/cm2 con cemento T-I | material |  |
| Canastilla 5/16" para dowells | material |  |
| PINTURA ASFALTICA | material |  |
| Roca | material | m3 |
| valvula compuerta elastomerica | material |  |
| Compuerta plana tipo tarjeta | material |  |
| Suministro de Compuerta plana tipo tarjeta 1.00 x 1.00m | material |  |
| Tubería HDPE Corrugado 630 mm | material |  |
| Tuberia HDPE NTP ISO 4427 PE-100 SDR 21 | material |  |

## Schedule

| ID | WBS | Activity | Type | Duration | Start | Finish | Predecessors | Total float | Free float | Resources | Cost |
| --- | --- | --- | --- | --- | --- | --- | --- | --- | --- | --- | --- |
|  | 2 | **HITOS** |  |  | 2024-06-01 | 2025-07-14 |  |  |  |  |  |
| A2670 |  | Inicio de obra - Acceso al Sitio | milestone | 0d | 2024-06-01 | 2024-06-01 |  | 0d |  |  |  |
| A2680 |  | Inicio de Obras Peliminares | milestone | 0d | 2024-06-21 | 2024-06-21 | A2670 SS+20d | 0d |  |  |  |
| A2690 |  | Inicio de Obras_ Quebrada San Jeronimo | milestone | 0d | 2024-07-15 | 2024-07-15 | A2680 SS+24d | 0d |  |  |  |
| A2700 |  | Inicio de Obras_ Quebrada San Condoray | milestone | 0d | 2024-07-15 | 2024-07-15 | A2680 SS+24d | 0d |  |  |  |
| A2710 |  | Inicio de Obras_ Quebrada San Jacayita | milestone | 0d | 2024-07-15 | 2024-07-15 | A2680 SS+24d | 5d | 0d |  |  |
| A2720 |  | Inicio de Obras_ Quebrada San Picamaran | milestone | 0d | 2024-07-15 | 2024-07-15 | A2680 SS+24d | 0d |  |  |  |
| A2750 |  | Culminación de Obras | milestone | 0d | 2025-07-14 | 2025-07-14 | A2670 SF+249d, A2780 FF, A1560 SF, A2740 FF, A5910 FF, A6170 FF, A6330 FF, A6310 FF | 1d |  |  |  |
|  | 5 | **TRABAJOS PRELIMINARES** |  |  | 2024-06-10 | 2025-07-14 |  |  |  |  |  |
| A1580 |  | Habilitación de plataformas |  | 36d | 2024-06-10 | 2024-07-15 | A2670 SS+2d, A2830 SS+7d | 1d | 0d | HH [324 h] | 567,146.28 |
| A6170 |  | Mantenimiento de caminos de acceso |  | 395d | 2024-06-15 | 2025-07-14 | A1580 SS+5d | 1d | 0d | HH [3555 h] | 794,145.76 |
| A5910 |  | Campamento Provisional de Obra |  | 388d | 2024-06-21 | 2025-07-13 | A2680 SS | 2d | 1d | HH [3492 h] | 2,090,295.07 |
|  | 12 | **CONSTRUCCION DE QUEBRADAS** |  |  | 2024-06-03 | 2025-07-15 |  |  |  |  |  |
|  | 1 | **CONSTRUCCION DE QUEBRADAS 2024** |  |  | 2024-06-03 | 2025-01-15 |  |  |  |  |  |
| A6190 |  | Produccion de Roca |  | 191d | 2024-06-20 | 2024-12-27 | A2830 SS+17d | 0d |  | HH [1719 h] |  |
| A6200 |  | Suministro de Roca 2024 |  | 136d | 2024-08-14 | 2024-12-27 | A6190 SS+55d | 0d |  | HH [1224 h]; Roca [29075 m3] |  |
|  | 4 | **OBRAS PROVISIONALES 2024** |  |  | 2024-06-03 | 2025-01-15 |  |  |  |  |  |
| A2830 |  | Movilización de Maquinaria Pesada |  | 30d | 2024-06-03 | 2024-07-02 | A2670 SS+2d | 0d |  | HH [270 h] | 992,040 |
| A2840 |  | Trazo y Replanteo Inicial |  | 194d | 2024-06-21 | 2024-12-31 | A2680 SS | 181d | 0d | HH [1746 h] | 43,103.7 |
| A1560 |  | Desmovilización |  | 15d | 2025-01-01 | 2025-01-15 | A2840 | 181d | 195d | HH [135 h] |  |
|  | 1 | **MANTENIMIENTO DE VIAS 2024** |  |  | 2024-06-23 | 2024-07-15 |  |  |  |  |  |
| A1590 |  | Mejoramiento y Habilitación de caminos de acceso |  | 23d | 2024-06-23 | 2024-07-15 | A2830 SS+20d | 206d | 0d | HH [207 h]; EXCAVADORA CAT 336 [207 h] | 278,414.02 |
| A1570 |  | Limpieza manual de material vegetal y de residuos |  | 5d | 2024-06-25 | 2024-06-29 | A1590 SS+2d | 206d | 0d | HH [45 h]; EXCAVADORA CAT 336 [45 h] | 10,579.8 |
|  | 11 | **QUEBRADA PICAMARAN** |  |  | 2024-07-15 | 2024-12-31 |  |  |  |  |  |
| A6220 |  | Inicio de Quebrada Picamaran | milestone | 0d | 2024-07-15 | 2024-07-15 | A2720 SS | 0d |  |  |  |
| A6230 |  | Fin de Quebrada Picamaran | milestone | 0d | 2024-12-31 | 2024-12-31 | A4510 FF, A4200 FF, A4170 FF, A4180 FF, A4310 FF, A4420 FF, A4400 FF, A4530 FF | 0d |  |  |  |

| ID | WBS | Activity | Duration | Start | Finish | Predecessors | Total float | Free float | Resources | Cost |
| --- | --- | --- | --- | --- | --- | --- | --- | --- | --- | --- |
|  | 1 | **DEMOLICIONES** |  | 2024-10-21 | 2024-10-31 |  |  |  |  |  |
| A4070 |  | Demolicion de Baden | 2d | 2024-10-21 | 2024-10-22 | A4340 SS | 38d | 0d | HH [18 h] | 5,339.73 |
| A4080 |  | Demolicion de Pavimentos | 7d | 2024-10-23 | 2024-10-29 | A4070 | 38d | 0d | HH [63 h] | 6,188.23 |
| A4110 |  | Eliminacion de material de demolicion | 2d | 2024-10-30 | 2024-10-31 | A4080 | 38d | 3d | HH [18 h] | 2,465.52 |
|  | 8 | **MOVIMIENTO DE TIERRAS** |  | 2024-07-15 | 2024-12-17 |  |  |  |  |  |
| A4120 |  | Desbroce | 10d | 2024-07-15 | 2024-07-24 | A2720 SS, A6220 SS | 0d |  | HH [90 h]; EXCAVADORA CAT 336 [90 h] | 16,628.64 |
| A4130 |  | Excavación de cimentación | 130d | 2024-07-25 | 2024-12-01 | A4120 | 0d |  | HH [1170 h]; EXCAVADORA CAT 336 [1170 h]; Excavación de cimentacion [62614] | 646,064.37 |
| A4140 |  | Perfilado y conformación de Plataforma de fundación | 100d | 2024-08-19 | 2024-11-26 | A4130 SS+25d | 55d | 0d | HH [900 h] | 62,442.54 |
| A4150 |  | Conformación de material excedente en DME | 78d | 2024-08-21 | 2024-11-06 | A4140 SS+2d | 55d | 0d | HH [702 h] | 223,299.53 |
| A4180 |  | Relleno Estructural | 65d | 2024-09-11 | 2024-11-14 | A4230 SS+15d, A4230 FF+6d | 47d |  | HH [585 h]; Relleno estructural [5337] | 566,320.68 |
| A4160 |  | Conformación de material excedente en DMO | 11d | 2024-10-27 | 2024-11-06 | A4150 SS+2d, A4150 FF | 55d | 0d | HH [99 h] | 27,514.44 |
| A4170 |  | Relleno con material granular (incluye extracción de material, zarandeo y combinación de material) | 5d | 2024-11-02 | 2024-11-06 | A4160 SS+2d, A4160 FF, A4180 SS | 55d |  | HH [45 h] | 37,184.4 |
| A4200 |  | Colocación de Roca en Uña | 3d | 2024-12-15 | 2024-12-17 | A4220 FS+2d, A4260 | 14d |  | HH [27 h]; EXCAVADORA CAT 336 [27 h] | 3,013.55 |
|  | 6 | **ROCA RECEBADA** |  | 2024-08-14 | 2024-12-14 |  |  |  |  |  |
| A4220 |  | Roca Recebada | 120d | 2024-08-14 | 2024-12-11 | A4130 SS+20d, A6200 SS | 0d |  | HH [1080 h]; EXCAVADORA CAT 336 [1080 h]; Colocación de roca recebada [15370] | 3,119,512.18 |
| A4260 |  | Emboquillado de piedra | 3d | 2024-12-12 | 2024-12-14 | A4220 | 14d | 0d | HH [27 h]; EXCAVADORA CAT 336 [27 h] |  |
|  | 2 | **MURO DE CONTENCIÓN CICLOPEO - Obras de Concreto Simple** |  | 2024-08-14 | 2024-10-15 |  |  |  |  |  |
| A4440 |  | Concreto Clase F (F'C=100 KG/CM2) - Solados | 19d | 2024-08-14 | 2024-09-01 | A4220 SS | 0d |  | HH [171 h]; Concreto premezclado F'C=100 kg/cm2 con cemento T-I [238] | 134,001.91 |
| A4470 |  | Encofrado y Desencofrado Cara Oculta | 47d | 2024-08-14 | 2024-09-29 | A4480 SS | 16d |  | HH [423 h] | 229,834.33 |
| A4480 |  | Encofrado y Desencofrado Cara Vista | 55d | 2024-08-14 | 2024-10-07 | A4440 SS | 8d | 0d | HH [495 h] | 180,289.18 |
| A4240 |  | Concreto Clase A (F'C=280 KG/CM2)- Premezclado - muros+30% PM DMAX=4" | 8d | 2024-08-19 | 2024-08-26 | A4450 SS | 0d |  | HH [72 h]; Concreto premezclado F'C=280 kg/cm2 con cemento T-I [40.41]; arena gruesa [2]; Cemento Portlamd Tipo I [99] | 23,003.39 |
| A4450 |  | Concreto Clase A (F'C=280 KG/CM2)- Premezclado - Losa | 44d | 2024-08-19 | 2024-10-01 | A4440 SS+5d | 0d |  | HH [396 h]; Concreto premezclado F'C=280 kg/cm2 con cemento T-I [707.41]; arena gruesa [40]; Cemento Portlamd Tipo I [1728] | 525,598.65 |
| A4230 |  | Concreto Clase A (F'C=280 KG/CM2)-Premezclado - muros +30% PM DMAX=6" | 50d | 2024-08-27 | 2024-10-15 | A4450 SS, A4240 | 0d |  | HH [450 h]; Concreto premezclado F'C=280 kg/cm2 con cemento T-I [2276]; Concreto premezclado F'C=280 kg/cm2 con cemento T-I [1012.5]; arena gruesa [113]; Cemento Portlamd Tipo I [4856] | 1,131,902.39 |
|  | 3 | **MURO DE CONTENCIÓN CON RAPIDA - Obras de Concreto Armado** |  | 2024-10-13 | 2024-11-25 |  |  |  |  |  |
| A4300 |  | Acero FY=4200 KG/CM2, Grado 60 | 32d | 2024-10-13 | 2024-11-13 | A4220 SS+60d | 5d | 0d | HH [288 h]; Acero Corrugado fy = 4200 kg/cm2 grado 60 [123293] | 668,611.07 |
| A4250 |  | Concreto Clase A (F'C=280 KG/CM2)- Premezclado - muros | 28d | 2024-10-16 | 2024-11-12 | A4230 | 0d |  | HH [252 h]; Concreto premezclado F'C=280 kg/cm2 con cemento T-I [714]; arena gruesa [41]; Cemento Portlamd Tipo I [1745] | 480,932.7 |
| A4280 |  | Encofrado y Desencofrado Cara Oculta | 19d | 2024-10-16 | 2024-11-03 | A4250 SS, A4470 | 0d |  | HH [171 h] | 28,127.13 |
| A4290 |  | Encofrado y Desencofrado Cara Vista | 26d | 2024-10-16 | 2024-11-10 | A4280 FF, A4280 SS, A4480 | 0d |  | HH [234 h] | 258,956.47 |
| A4320 |  | Tubo PVC - D=6" | 4d | 2024-10-26 | 2024-10-29 | A4250 SS+10d | 51d | 0d | HH [36 h] | 5,816.62 |
| A4460 |  | Junta de dilatacion | 20d | 2024-10-28 | 2024-11-16 | A4300 SS+15d | 36d | 0d | HH [180 h] |  |
| A4330 |  | Tubo PVC - D=4" | 3d | 2024-10-30 | 2024-11-01 | A4320 | 51d | 15d | HH [27 h] | 4,022.55 |
| A4310 |  | Geocompuesto de Drenaje | 9d | 2024-11-17 | 2024-11-25 | A4330, A4460 | 36d |  | HH [81 h]; Geocompuesto de Drenaje [294] | 22,161.74 |

| ID | WBS | Activity | Duration | Start | Finish | Predecessors | Total float | Free float | Resources | Cost |
| --- | --- | --- | --- | --- | --- | --- | --- | --- | --- | --- |
|  | 4 | **PASO SUPERIOR TIPO MARCO** |  | 2024-10-21 | 2024-12-12 |  |  |  |  |  |
|  | 1 | **Obras de Concreto Simple** |  | 2024-10-21 | 2024-10-24 |  |  |  |  |  |
| A4340 |  | Encofrado y Desencofrado en Estructuras | 2d | 2024-10-21 | 2024-10-22 | A4290 SS+5d | 25d | 0d | HH [18 h] | 1,034.7 |
| A4600 |  | Concreto Clase F (F'C=100 KG/CM2) - Solados | 2d | 2024-10-23 | 2024-10-24 | A4340 | 25d | 20d | HH [18 h]; Concreto premezclado F'C=100 kg/cm2 con cemento T-I [23] | 12,653.99 |
|  | 2 | **Obras de Concreto Armado** |  | 2024-11-04 | 2024-12-12 |  |  |  |  |  |
| A4370 |  | Encofrado y Desencofrado Cara Oculta | 18d | 2024-11-04 | 2024-11-21 | A4280, A4110 | 35d |  | HH [162 h] | 22,509.44 |
| A4380 |  | Encofrado y Desencofrado Cara Vista | 18d | 2024-11-11 | 2024-11-28 | A4290 | 0d |  | HH [162 h] | 53,681.78 |
| A4390 |  | Acero FY=4200 KG/CM2, Grado 60 | 15d | 2024-11-14 | 2024-11-28 | A4300, A4600 | 5d |  | HH [135 h]; Acero Corrugado fy = 4200 kg/cm2 grado 60 [37802] | 194,613.49 |
| A4360 |  | Concreto Clase A(F'C=280 KG/CM2)- Premezclado - Cimentacion | 10d | 2024-11-19 | 2024-11-28 | A4380 FF, A4390 SS | 0d |  | HH [90 h]; Concreto premezclado F'C=280 kg/cm2 con cemento T-I [166.64]; arena gruesa [9]; Cemento Portlamd Tipo I [407] | 127,517.93 |
| A4350 |  | Concreto Clase A(F'C=280 KG/CM2)- Premezclado - muros | 13d | 2024-11-21 | 2024-12-03 | A4360 SS+2d | 0d |  | HH [117 h]; Concreto premezclado F'C=280 kg/cm2 con cemento T-I [168.77]; arena gruesa [10]; Cemento Portlamd Tipo I [412] | 130,455.83 |
| A4410 |  | Tubo PVC - D=6" | 1d | 2024-11-26 | 2024-11-26 | A4350 SS+5d, A4320 | 34d | 0d | HH [9 h] | 706.72 |
| A4650 |  | Pintura Bituminosa | 8d | 2024-11-26 | 2024-12-03 | A4350 SS+5d | 26d | 0d | HH [72 h]; PINTURA ASFALTICA [363] | 11,445.06 |
| A4420 |  | Tubo PVC - D=4" | 1d | 2024-11-27 | 2024-11-27 | A4410, A4330 | 34d |  | HH [9 h] | 429.07 |
| A4430 |  | Baranda Metalica Tipica H=0.50M | 2d | 2024-11-29 | 2024-11-30 | A4350 SS+8d | 29d | 3d | HH [18 h]; Baranda Metalica [19 m3] | 10,186.28 |
| A4400 |  | Geocompuesto de Drenaje | 2d | 2024-12-04 | 2024-12-05 | A4650, A4430 | 26d |  | HH [18 h]; Geocompuesto de Drenaje [48] | 2,333.67 |
| A4610 |  | Concreto Clase A(F'C=280 KG/CM2)- Premezclado - losas | 9d | 2024-12-04 | 2024-12-12 | A4390 SS+7d, A4350 | 0d |  | HH [81 h]; Concreto premezclado F'C=280 kg/cm2 con cemento T-I [109.08]; arena gruesa [6]; Cemento Portlamd Tipo I [266] | 85,880.94 |
|  | 5 | **PAVIMENTO RIGIDO** |  | 2024-12-13 | 2024-12-31 |  |  |  |  |  |
| A4210 |  | Subbase granular | 2d | 2024-12-13 | 2024-12-14 | A4610, A4360 | 0d |  | HH [18 h] |  |
| A4520 |  | Acero FY=4200 KG/CM2, Grado 60 | 8d | 2024-12-15 | 2024-12-22 | A4210 | 9d |  | HH [72 h]; Acero Corrugado fy = 4200 kg/cm2 grado 60 [7612] | 12,081.64 |
| A4540 |  | Acero Longitudinal (Barra de amarre Ø1/2" Corrugado) | 7d | 2024-12-16 | 2024-12-22 | A4210 FS+1d | 9d |  | HH [63 h] | 858.66 |
| A4550 |  | Acero Transversal (Pasa Juntas Dowells Ø 1 1/4" Liso) | 3d | 2024-12-17 | 2024-12-19 | A4210 FS+2d | 0d |  | HH [27 h] | 6,422.03 |
| A4590 |  | Junta de Aislamiento | 7d | 2024-12-19 | 2024-12-25 | A4210 SS+2d, A4550 SS+2d, A4550 FF, A4210 FF | 4d |  | HH [63 h] | 1,326.17 |
| A4560 |  | Canastilla para Ø5/16" para Dowells | 4d | 2024-12-21 | 2024-12-24 | A4210 SS, A4550 SS+4d, A4550 FF, A4210 FF | 0d |  | HH [36 h]; Canastilla 5/16" para dowells [1141] | 18,389.35 |
| A4580 |  | Junta Transversal de Contraccion | 6d | 2024-12-21 | 2024-12-26 | A4210 SS, A4550 SS, A4560 SS, A4560 FF, A4550 FF, A4210 FF | 0d |  | HH [54 h] | 1,317.96 |
| A4530 |  | Encofrado y Desencofrado de Pavimientos | 5d | 2024-12-27 | 2024-12-31 | A4550 FF, A4520 FF, A4540 FF, A4570 SS, A4370 | 0d |  | HH [45 h] | 1,252.74 |
| A4570 |  | Concreto Clase A (F'C=280 KG/CM2)- Premezclado - Losas | 4d | 2024-12-27 | 2024-12-30 | A4590 FF+1d, A4580, A4590 SS | 0d |  | HH [36 h]; Concreto premezclado F'C=280 kg/cm2 con cemento T-I [41.79]; arena gruesa [2]; Cemento Portlamd Tipo I [102] | 1,428.3 |
| A4510 |  | Pavimiento Hidraulico (F'C 300KG/CM2) | 4d | 2024-12-28 | 2024-12-31 | A4570 SS+1d | 0d |  | HH [36 h] | 36,541.26 |

| ID | WBS | Activity | Type | Duration | Start | Finish | Predecessors | Total float | Free float | Resources | Cost |
| --- | --- | --- | --- | --- | --- | --- | --- | --- | --- | --- | --- |
|  | 10 | **QUEBRADA JACAYITA 2024** |  |  | 2024-07-15 | 2024-09-18 |  |  |  |  |  |
| A6260 |  | Inicio de Quebrada Jacayita | milestone | 0d | 2024-07-15 | 2024-07-15 | A2710 SS | 118d | 0d |  |  |
| A6270 |  | Fin de Quebrada Jacayita | milestone | 0d | 2024-09-18 | 2024-09-18 | A3600 FF | 104d |  |  |  |
|  | 8 | **MOVIMIENTO DE TIERRAS** |  |  | 2024-07-15 | 2024-09-18 |  |  |  |  |  |
| A3520 |  | Desbroce |  | 1d | 2024-07-15 | 2024-07-15 | A6260 SS | 118d | 0d | HH [9 h]; EXCAVADORA CAT 336 [9 h] | 8,345.7 |
| A3530 |  | Excavación de cimentación |  | 25d | 2024-07-16 | 2024-08-09 | A3520 | 118d | 0d | HH [225 h]; EXCAVADORA CAT 336 [225 h]; Excavación de cimentacion [8034] | 371,933.31 |
| A3540 |  | Perfilado y conformación de Plataforma de fundación |  | 25d | 2024-07-18 | 2024-08-11 | A3530 SS+2d | 196d | 0d | HH [225 h] | 30,981.78 |
| A3550 |  | Conformación de material excedente en DME |  | 11d | 2024-07-23 | 2024-08-02 | A3540 SS+5d | 196d | 0d | HH [99 h] | 129,697.33 |
| A3560 |  | Conformación de material excedente en DMO |  | 2d | 2024-08-01 | 2024-08-02 | A3550 SS+2d, A3550 FF | 196d | 0d | HH [18 h] | 13,735.59 |
| A3570 |  | Relleno con material granular (incluye extracción de material, zarandeo y combinación de material) |  | 1d | 2024-08-03 | 2024-08-03 | A3560 SS+2d, A3560 FF | 196d | 0d | HH [9 h] | 5,595.68 |
| A3600 |  | Colocación de Roca en Uña |  | 6d | 2024-09-13 | 2024-09-18 | A3620 | 104d | 0d | HH [54 h]; EXCAVADORA CAT 336 [54 h] | 77,516.02 |
|  | 6 | **ROCA RECEBADA** |  |  | 2024-08-24 | 2024-09-12 |  |  |  |  |  |
| A3620 |  | Roca Recebada |  | 20d | 2024-08-24 | 2024-09-12 | A6200 SS+10d, A3530 | 104d | 0d | HH [180 h]; EXCAVADORA CAT 336 [180 h]; Colocación de roca recebada [1441] | 1,274,041.4 |
|  | 6 | **QUEBRADA CONDORAY** |  |  | 2024-07-15 | 2024-12-31 |  |  |  |  |  |
| A6240 |  | Inicio de Quebrada Condoray | milestone | 0d | 2024-07-15 | 2024-07-15 | A2700 SS | 0d |  |  |  |
| A6250 |  | Fin de Quebrada Condoray | milestone | 0d | 2024-12-31 | 2024-12-31 | A3310 FF, A2970 FF, A2980 FF, A2910 FF, A3040 FF, A3090 FF, A3260 FF, A3050 FF, A3200 FF | 0d |  |  |  |
|  | 1 | **DEMOLICIONES** |  |  | 2024-07-15 | 2024-11-10 |  |  |  |  |  |
| A2860 |  | Demolicion de Canales en Quebradas |  | 27d | 2024-07-15 | 2024-08-10 | A2700 SS, A6240 SS | 0d |  | HH [243 h] | 181,200.67 |
| A6160 |  | Eliminacion de material de demolicion canales en quebradas |  | 14d | 2024-08-11 | 2024-08-24 | A2860 | 2d |  | HH [126 h] | 49,533.35 |
| A2870 |  | Demolicion de Baden |  | 5d | 2024-10-17 | 2024-10-21 | A3140 | 51d | 0d | HH [45 h] | 15,382.36 |
| A2880 |  | Demolicion de Pavimentos |  | 11d | 2024-10-17 | 2024-10-27 | A2870 SS, A2870 FF, A6160 | 51d | 0d | HH [99 h] | 34,988.05 |
| A2910 |  | Eliminacion de material de demolicion de baden y pavimientos |  | 14d | 2024-10-28 | 2024-11-10 | A2880 | 51d |  | HH [126 h] | 49,533.35 |
|  | 8 | **MOVIMIENTO DE TIERRAS** |  |  | 2024-08-13 | 2024-12-13 |  |  |  |  |  |
| A2920 |  | Desbroce |  | 3d | 2024-08-13 | 2024-08-15 | A2700 SS+7d, A2860 FS+2d, A6160 SS | 0d |  | HH [27 h]; EXCAVADORA CAT 336 [27 h] | 11,671.43 |
| A2930 |  | Excavación de cimentación |  | 64d | 2024-08-16 | 2024-10-18 | A2920 | 0d |  | HH [576 h]; EXCAVADORA CAT 336 [576 h]; Excavación de cimentacion [31782] | 335,392.89 |
| A2940 |  | Perfilado y conformación de Plataforma de fundación |  | 12d | 2024-08-18 | 2024-08-29 | A2930 SS+2d | 90d | 0d | HH [108 h] | 42,565.59 |
| A2950 |  | Conformación de material excedente en DME |  | 44d | 2024-08-20 | 2024-10-02 | A2940 SS+2d | 90d | 0d | HH [396 h] | 127,182.7 |
| A2960 |  | Conformación de material excedente en DMO |  | 7d | 2024-09-26 | 2024-10-02 | A2950 SS+2d, A2950 FF | 90d | 0d | HH [63 h] | 19,200.25 |
| A2970 |  | Relleno con material granular (incluye extracción de material, zarandeo y combinación de material) |  | 2d | 2024-10-01 | 2024-10-02 | A2960 SS+2d, A2960 FF | 90d |  | HH [18 h] | 290.06 |
| A3000 |  | Colocación de Roca en Uña |  | 2d | 2024-10-21 | 2024-10-22 | A3020 | 18d | 0d | HH [18 h]; EXCAVADORA CAT 336 [18 h] | 4,141.82 |
| A2980 |  | Relleno Estructural |  | 52d | 2024-10-23 | 2024-12-13 | A3030 SS, A3030 FF, A3000 | 18d |  | HH [468 h]; Relleno estructural [8621] | 886,396.07 |

| ID | WBS | Activity | Duration | Start | Finish | Predecessors | Total float | Free float | Resources | Cost |
| --- | --- | --- | --- | --- | --- | --- | --- | --- | --- | --- |
|  | 6 | **ROCA RECEBADA** |  | 2024-08-16 | 2024-10-20 |  |  |  |  |  |
| A3020 |  | Roca Recebada | 66d | 2024-08-16 | 2024-10-20 | A6200 SS+2d, A2930 SS | 0d |  | HH [594 h]; EXCAVADORA CAT 336 [594 h]; Colocación de roca recebada [8673] | 1,814,120.25 |
|  | 3 | **MURO DE CONTENCIÓN CICLOPEO-Obras de Concreto Simple** |  | 2024-08-23 | 2024-11-28 |  |  |  |  |  |
| A3240 |  | Concreto Clase F (F'C=100 KG/CM2) - Solados | 23d | 2024-08-23 | 2024-09-14 | A3020 SS+7d | 0d |  | HH [207 h]; Concreto premezclado F'C=100 kg/cm2 con cemento T-I [306] | 172,295.4 |
| A3280 |  | Encofrado y Desencofrado Cara Vista | 81d | 2024-09-09 | 2024-11-28 | A3270 FF | 0d |  | HH [729 h] | 196,201.76 |
| A3270 |  | Encofrado y Desencofrado Cara Oculta | 76d | 2024-09-14 | 2024-11-28 | A3240 SS+22d, A3240 FF | 0d |  | HH [684 h] | 249,733.13 |
| A3030 |  | Concreto Clase A (F'C=280 KG/CM2)-Premezclado - muros +30% PM DMAX=6" | 65d | 2024-09-25 | 2024-11-28 | A3280 FF, A3280 SS | 0d |  | HH [585 h]; Concreto premezclado F'C=280 kg/cm2 con cemento T-I [2898.09]; arena gruesa [148]; Cemento Portlamd Tipo I [6375] | 1,485,901.89 |
| A3250 |  | Concreto Clase A (F'C=280 KG/CM2)- Premezclado - Losa | 33d | 2024-10-27 | 2024-11-28 | A3280 FF, A3280 SS | 33d | 0d | HH [297 h]; Concreto premezclado F'C=280 kg/cm2 con cemento T-I [546.46]; arena gruesa [31]; Cemento Portlamd Tipo I [1335] | 400,260.09 |
| A3040 |  | Concreto Clase A (F'C=280 KG/CM2)- Premezclado - muros+30% PM DMAX=4" | 3d | 2024-11-26 | 2024-11-28 | A3280 FF, A3250 SS+1d, A3250 FF | 33d |  | HH [27 h]; Concreto premezclado F'C=280 kg/cm2 con cemento T-I [32.75]; arena gruesa [2]; Cemento Portlamd Tipo I [80] | 18,642.94 |
|  | 2 | **MURO DE CONTENCIÓN CON RAPIDA - Obras de Concreto Armado** |  | 2024-10-24 | 2024-12-31 |  |  |  |  |  |
| A3080 |  | Encofrado y Desencofrado Cara Oculta | 67d | 2024-10-24 | 2024-12-29 | A3270 SS+40d | 0d |  | HH [603 h] | 31,914.6 |
| A3090 |  | Encofrado y Desencofrado Cara Vista | 69d | 2024-10-24 | 2024-12-31 | A3080 SS | 0d |  | HH [621 h] | 230,506.36 |
| A3100 |  | Acero FY=4200 KG/CM2, Grado 60 | 58d | 2024-10-24 | 2024-12-20 | A3270 SS+40d | 3d | 0d | HH [522 h]; Acero Corrugado fy = 4200 kg/cm2 grado 60 [117384] | 663,490.34 |
| A3050 |  | Concreto Clase A (F'C=280 KG/CM2)- Premezclado - muros | 43d | 2024-11-19 | 2024-12-31 | A3030 SS+55d | 0d |  | HH [387 h]; Concreto premezclado F'C=280 kg/cm2 con cemento T-I [640.72]; arena gruesa [36]; Cemento Portlamd Tipo I [1565] | 495,263.75 |
| A3110 |  | Geocompuesto de Drenaje | 15d | 2024-12-13 | 2024-12-27 | A3120 SS | 11d | 8d | HH [135 h]; Geocompuesto de Drenaje [535] | 25,624.42 |
| A3120 |  | Tubo PVC - D=6" | 8d | 2024-12-13 | 2024-12-20 | A3080 SS+15d, A3100 SS, A3100 FF | 3d | 0d | HH [72 h] | 7,061.7 |
| A3130 |  | Tubo PVC - D=4" | 6d | 2024-12-21 | 2024-12-26 | A3120 | 3d | 0d | HH [54 h] | 4,880.69 |
| A3260 |  | Junta de dilatación | 8d | 2024-12-21 | 2024-12-28 | A3110 SS, A3130 SS | 3d |  | HH [72 h] |  |
|  | 4 | **PASO SUPERIOR TIPO MARCO** |  | 2024-10-15 | 2024-11-28 |  |  |  |  |  |
|  | 1 | **Obras de Concreto Simple** |  | 2024-10-15 | 2024-10-18 |  |  |  |  |  |
| A3140 |  | Encofrado y Desencofrado en Estructuras | 2d | 2024-10-15 | 2024-10-16 | A3020 SS+60d | 0d |  | HH [18 h] | 1,035.74 |
| A3400 |  | Concreto Clase F (F'C=100 KG/CM2) - Solados | 2d | 2024-10-17 | 2024-10-18 | A3140 | 0d |  | HH [18 h]; Concreto premezclado F'C=100 kg/cm2 con cemento T-I [21] | 11,856.09 |
|  | 2 | **Obras de Concreto Armado** |  | 2024-11-02 | 2024-11-28 |  |  |  |  |  |
| A3170 |  | Encofrado y Desencofrado Cara Oculta | 13d | 2024-11-02 | 2024-11-14 | A3190 SS | 0d |  | HH [117 h] | 21,519.03 |
| A3180 |  | Encofrado y Desencofrado Cara Vista | 15d | 2024-11-02 | 2024-11-16 | A3170 SS, A3170 FF | 0d |  | HH [135 h] | 51,800.77 |
| A3190 |  | Acero FY=4200 KG/CM2, Grado 60 | 17d | 2024-11-02 | 2024-11-18 | A3400 FS+14d | 0d |  | HH [153 h]; Acero Corrugado fy = 4200 kg/cm2 grado 60 [37885] | 191,031.86 |
| A3160 |  | Concreto Clase A(F'C=280 KG/CM2)- Premezclado - Cimentacion | 13d | 2024-11-07 | 2024-11-19 | A3180 FF+3d | 0d |  | HH [117 h]; Concreto premezclado F'C=280 kg/cm2 con cemento T-I [110.91]; arena gruesa [9]; Cemento Portlamd Tipo I [403] | 126,347.13 |
| A3150 |  | Concreto Clase A(F'C=280 KG/CM2)- Premezclado - muros | 12d | 2024-11-08 | 2024-11-19 | A3160 SS+1d | 0d |  | HH [108 h]; Concreto premezclado F'C=280 kg/cm2 con cemento T-I [152.38]; arena gruesa [9]; Cemento Portlamd Tipo I [372] | 117,786.69 |
| A3450 |  | Pintura Bituminosa | 8d | 2024-11-12 | 2024-11-19 | A3150 SS+4d | 0d |  | HH [363 h]; PINTURA ASFALTICA [72] | 11,453.57 |
| A3210 |  | Tubo PVC - D=6" | 2d | 2024-11-13 | 2024-11-14 | A3150 SS+5d | 43d | 0d | HH [18 h] | 696.7 |
| A3220 |  | Tubo PVC - D=4" | 2d | 2024-11-15 | 2024-11-16 | A3210 | 43d | 5d | HH [18 h] | 429.07 |
| A3230 |  | Baranda Metalica Tipica H=0.50M | 2d | 2024-11-20 | 2024-11-21 | A3150 | 38d | 0d | HH [18 h]; Baranda Metalica [19 m3] | 10,079.06 |
| A3290 |  | Junta de dilatación con poliestireno expandido | 2d | 2024-11-20 | 2024-11-21 | A3450 | 0d |  | HH [18 h] |  |
| A3410 |  | Concreto Clase A(F'C=280 KG/CM2)- Premezclado - losas | 9d | 2024-11-20 | 2024-11-28 | A3150, A3290 SS | 0d |  | HH [81 h]; Concreto premezclado F'C=280 kg/cm2 con cemento T-I [165.11]; arena gruesa [6]; Cemento Portlamd Tipo I [271] | 84,533.21 |
| A3200 |  | Geocompuesto de Drenaje | 2d | 2024-11-22 | 2024-11-23 | A3220, A3160, A3230 | 38d |  | HH [18 h]; Geocompuesto de Drenaje [48] | 2,300.63 |

| ID | WBS | Activity | Type | Duration | Start | Finish | Predecessors | Total float | Free float | Resources | Cost |
| --- | --- | --- | --- | --- | --- | --- | --- | --- | --- | --- | --- |
|  | 5 | **PAVIMENTO RIGIDO** |  |  | 2024-12-15 | 2024-12-31 |  |  |  |  |  |
| A3010 |  | Subbase granular |  | 2d | 2024-12-15 | 2024-12-16 | A3410 SS+25d | 0d |  | HH [18 h] |  |
| A3330 |  | Encofrado y Desencofrado de Pavimientos |  | 6d | 2024-12-16 | 2024-12-21 | A3350 FF, A3340 FF | 7d |  | HH [54 h] | 3,100.16 |
| A3320 |  | Acero FY=4200 KG/CM2, Grado 60 |  | 12d | 2024-12-17 | 2024-12-28 | A3010 | 0d |  | HH [108 h]; Acero Corrugado fy = 4200 kg/cm2 grado 60 [4086] | 19,767.2 |
| A3340 |  | Acero Longitudinal (Barra de amarre Ø1/2" Corrugado) |  | 3d | 2024-12-18 | 2024-12-20 | A3010 FS+1d | 8d | 1d | HH [27 h] | 2,094.3 |
| A3350 |  | Acero Transversal (Pasa Juntas Dowells Ø 1 1/4" Liso) |  | 3d | 2024-12-19 | 2024-12-21 | A3010 FS+2d | 0d |  | HH [27 h] | 5,606.4 |
| A3390 |  | Junta de Aislamiento |  | 1d | 2024-12-21 | 2024-12-21 | A3010 SS+2d, A3350 SS+2d, A3350 FF, A3010 FF | 7d |  | HH [9 h] | 1,301.58 |
| A3360 |  | Canastilla para Ø5/16" para Dowells |  | 6d | 2024-12-23 | 2024-12-28 | A3010 SS, A3350 SS+4d, A3350 FF, A3010 FF | 0d |  | HH [54 h]; Canastilla 5/16" para dowells [361] | 42,553.05 |
| A3380 |  | Junta Transversal de Contraccion |  | 4d | 2024-12-25 | 2024-12-28 | A3010 SS, A3350 SS, A3360 SS, A3360 FF, A3350 FF, A3010 FF | 0d |  | HH [36 h] | 2,626.68 |
| A3370 |  | Concreto Clase A (F'C=280 KG/CM2)- Premezclado - Losas |  | 1d | 2024-12-29 | 2024-12-29 | A3390 FF+1d, A3380, A3390 SS, A3330, A3320 | 0d |  | HH [9 h]; Concreto premezclado F'C=280 kg/cm2 con cemento T-I [2.52]; arena gruesa; Cemento Portlamd Tipo I [6] | 1,845.8 |
| A3310 |  | Pavimiento Hidraulico (F'C 300KG/CM2) |  | 2d | 2024-12-30 | 2024-12-31 | A3370 | 0d |  | HH [18 h] | 109,878.99 |
|  | 3 | **QUEBRADA SAN JERONIMO 2024** |  |  | 2024-07-15 | 2024-12-31 |  |  |  |  |  |
| A6280 |  | Inicio de Quebrada San Jeronimo | milestone | 0d | 2024-07-15 | 2024-07-15 | A2690 SS | 31d |  |  |  |
| A6290 |  | Fin de Quebrada San Jeronimo | milestone | 0d | 2024-12-31 | 2024-12-31 | A5310 FF, A5300 FF, A5420 FF, A5820 FF, A5630 FF, A5830 FF, A5640 FF, A5660 FF | 0d |  |  |  |
|  | 1 | **DEMOLICIONES** |  |  | 2024-08-04 | 2024-08-25 |  |  |  |  |  |
| A5200 |  | Demolicion de Baden |  | 4d | 2024-08-04 | 2024-08-07 | A2690 SS+20d | 0d |  | HH [36 h] | 14,686.22 |
| A5210 |  | Demolicion de Pavimentos |  | 7d | 2024-08-08 | 2024-08-14 | A5200 | 0d |  | HH [63 h] | 32,837.09 |
| A5220 |  | Demolicion de Veredas |  | 1d | 2024-08-15 | 2024-08-15 | A5210 | 67d | 0d | HH [9 h] | 380.15 |
| A5240 |  | Eliminacion de material de demolicion |  | 10d | 2024-08-16 | 2024-08-25 | A5210, A5220 | 67d | 12d | HH [90 h] | 33,499.6 |
|  | 8 | **MOVIMIENTO DE TIERRAS** |  |  | 2024-08-15 | 2024-12-31 |  |  |  |  |  |
| A5250 |  | Desbroce |  | 3d | 2024-08-15 | 2024-08-17 | A5210, A6280 SS | 0d |  | HH [27 h]; EXCAVADORA CAT 336 [27 h] | 16,314.9 |
| A5260 |  | Excavación de cimentación |  | 92d | 2024-08-18 | 2024-11-17 | A5250 | 0d |  | HH [828 h]; EXCAVADORA CAT 336 [828 h]; Excavación de cimentacion [47097] | 802,937.21 |
| A5280 |  | Conformación de material excedente en DME |  | 61d | 2024-09-07 | 2024-11-06 | A5260 SS+20d, A5240 | 55d | 0d | HH [549 h] | 282,808.47 |
| A5310 |  | Relleno Estructural |  | 73d | 2024-09-26 | 2024-12-07 | A5360 SS+10d, A5360 FF | 24d |  | HH [657 h]; Relleno estructural [12057] | 1,908,574.23 |
| A5290 |  | Conformación de material excedente en DMO |  | 6d | 2024-11-01 | 2024-11-06 | A5280 SS+2d, A5280 FF | 55d | 0d | HH [54 h] | 26,931.29 |
| A5300 |  | Relleno con material granular (incluye extracción de material, zarandeo y combinación de material) |  | 2d | 2024-11-05 | 2024-11-06 | A5290 SS+2d, A5290 FF | 55d |  | HH [18 h] | 8,109.5 |
| A5270 |  | Perfilado y conformación de Plataforma de fundación |  | 10d | 2024-11-08 | 2024-11-17 | A5260 SS, A5260 FF | 196d | 0d | HH [90 h] | 62,425.71 |
| A5330 |  | Colocación de Roca en Uña |  | 5d | 2024-12-27 | 2024-12-31 | A5350 | 196d |  | HH [45 h]; EXCAVADORA CAT 336 [45 h] | 25,461.96 |

| ID | WBS | Activity | Duration | Start | Finish | Predecessors | Total float | Free float | Resources | Cost |
| --- | --- | --- | --- | --- | --- | --- | --- | --- | --- | --- |
|  | 6 | **ROCA RECEBADA** |  | 2024-11-18 | 2024-12-26 |  |  |  |  |  |
| A5350 |  | Roca Recebada | 39d | 2024-11-18 | 2024-12-26 | A5260, A6200 SS, A5270 | 196d | 0d | HH [351 h]; EXCAVADORA CAT 336 [351 h]; Colocación de roca recebada [5417] | 1,820,435.73 |
|  | 2 | **MURO DE CONTENCIÓN CICLOPEO - Obras de Concreto Simple** |  | 2024-08-18 | 2024-12-07 |  |  |  |  |  |
| A5570 |  | Concreto Clase F (F'C=100 KG/CM2) - Solados | 29d | 2024-08-18 | 2024-09-15 | A5260 SS | 0d |  | HH [261 h]; Concreto premezclado F'C=100 kg/cm2 con cemento T-I [382] | 215,190.84 |
| A5360 |  | Concreto Clase A (F'C=280 KG/CM2)-Premezclado - muros +30% PM DMAX=6" | 107d | 2024-08-23 | 2024-12-07 | A5610 FF, A5610 SS | 24d | 0d | HH [963 h]; Concreto premezclado F'C=280 kg/cm2 con cemento T-I [8791]; arena gruesa [483]; Cemento Portlamd Tipo I [20768] | 4,840,611.68 |
| A5600 |  | Encofrado y Desencofrado Cara Oculta | 103d | 2024-08-23 | 2024-12-03 | A5570 SS+5d, A5570 FF | 9d | 0d | HH [927 h] | 678,862.3 |
| A5610 |  | Encofrado y Desencofrado Cara Vista | 79d | 2024-08-23 | 2024-11-09 | A5570 SS+5d | 11d | 0d | HH [711 h] | 519,099.23 |
| A5580 |  | Concreto Clase A (F'C=280 KG/CM2)- Premezclado - Losa | 40d | 2024-10-01 | 2024-11-09 | A5610 FF, A5610 SS | 11d | 0d | HH [360 h]; Concreto premezclado F'C=280 kg/cm2 con cemento T-I [647.7]; arena gruesa [37]; Cemento Portlamd Tipo I [1582] | 474,414.34 |
| A5370 |  | Concreto Clase A (F'C=280 KG/CM2)- Premezclado - muros+30% PM DMAX=4" | 8d | 2024-11-02 | 2024-11-09 | A5610 FF, A5580 SS+1d, A5580 FF | 11d |  | HH [72 h]; Concreto premezclado F'C=280 kg/cm2 con cemento T-I [103.7]; arena gruesa [6]; Cemento Portlamd Tipo I [253] | 59,031.23 |
|  | 3 | **MURO DE CONTENCIÓN CON RAPIDA - Obras de Concreto Armado** |  | 2024-08-23 | 2024-12-31 |  |  |  |  |  |
| A5410 |  | Encofrado y Desencofrado Cara Oculta | 121d | 2024-08-23 | 2024-12-21 | A5570 SS+5d | 0d |  | HH [1089 h] | 62,805.63 |
| A5420 |  | Encofrado y Desencofrado Cara Vista | 121d | 2024-08-23 | 2024-12-21 | A5410 FF | 10d |  | HH [1089 h] | 399,999.58 |
| A5430 |  | Acero FY=4200 KG/CM2, Grado 60 | 100d | 2024-08-23 | 2024-11-30 | A5600 SS | 21d |  | HH [900 h]; Acero Corrugado fy = 4200 kg/cm2 grado 60 [238410] | 1,392,322.65 |
| A5380 |  | Concreto Clase A (F'C=280 KG/CM2)- Premezclado - muros | 89d | 2024-09-24 | 2024-12-21 | A5410 FF, A5410 SS, A5430 SS, A5430 FF | 0d |  | HH [801 h]; Concreto premezclado F'C=280 kg/cm2 con cemento T-I [1441]; arena gruesa [66]; Cemento Portlamd Tipo I [2817] | 891,586.05 |
| A5440 |  | Geocompuesto de Drenaje | 31d | 2024-11-21 | 2024-12-21 | A5380 SS, A5380 FF, A5370 | 0d |  | HH [279 h]; Geocompuesto de Drenaje [2049] | 98,136.28 |
| A5450 |  | Tubo PVC - D=6" | 22d | 2024-11-21 | 2024-12-12 | A5440 SS | 0d |  | HH [198 h] | 19,317.74 |
| A5460 |  | Tubo PVC - D=4" | 16d | 2024-11-27 | 2024-12-12 | A5450 SS, A5450 FF | 0d |  | HH [144 h] | 13,193.96 |
| A5820 |  | Junta de Dilatación | 19d | 2024-12-13 | 2024-12-31 | A5440 SS+20d, A5460 | 0d |  | HH [171 h] |  |
|  | 12 | **MUROS DE CONTENCIÓN** |  | 2024-09-24 | 2024-10-22 |  |  |  |  |  |
|  | 1 | **Obras de Concreto Simple** |  | 2024-09-24 | 2024-09-25 |  |  |  |  |  |
| A5750 |  | Concreto Clase F (F'C=100 KG/CM2) - Solados | 2d | 2024-09-24 | 2024-09-25 | A5380 SS | 70d | 0d | HH [18 h]; Concreto premezclado F'C=100 kg/cm2 con cemento T-I [14] | 8,007.08 |
|  | 2 | **Obras de Concreto Armado** |  | 2024-09-26 | 2024-10-22 |  |  |  |  |  |
| A5390 |  | Encofrado y Desencofrado Cara Oculta | 16d | 2024-09-26 | 2024-10-11 | A5750 | 70d | 0d | HH [144 h] | 20,356.13 |
| A5400 |  | Encofrado y Desencofrado Cara Vista | 16d | 2024-09-26 | 2024-10-11 | A5390 FF, A5620 FF | 70d | 0d | HH [144 h] | 21,808.78 |
| A5620 |  | Acero FY=4200 KG/CM2, Grado 60 | 11d | 2024-09-29 | 2024-10-09 | A5750 FS+3d | 72d | 2d | HH [99 h]; Acero Corrugado fy = 4200 kg/cm2 grado 60 [6910] | 36,949.35 |
| A5590 |  | Concreto Clase A (F'C=280 KG/CM2)- Premezclado - Cimentacion | 4d | 2024-10-12 | 2024-10-15 | A5400 | 70d | 0d | HH [36 h]; Concreto premezclado F'C=280 kg/cm2 con cemento T-I [62.66]; arena gruesa [4]; Cemento Portlamd Tipo I [153] | 48,446.71 |
| A5760 |  | Concreto Clase A (F'C=280 KG/CM2)- Premezclado - Muros | 5d | 2024-10-16 | 2024-10-20 | A5590 | 70d | 0d | HH [45 h]; Concreto premezclado F'C=280 kg/cm2 con cemento T-I [50.52]; arena gruesa [3]; Cemento Portlamd Tipo I [123] | 39,460.63 |
| A5770 |  | Pintura Bituminosa | 5d | 2024-10-16 | 2024-10-20 | A5760 SS | 70d | 0d | HH [45 h]; PINTURA ASFALTICA [216] | 6,881.47 |
| A5630 |  | Barrera de Seguridad Rigida Tipo New Jersey Prefabricada | 2d | 2024-10-21 | 2024-10-22 | A5760, A5770 | 70d |  | HH [18 h] | 9,122.25 |

| ID | WBS | Activity | Duration | Start | Finish | Predecessors | Total float | Free float | Resources | Cost |
| --- | --- | --- | --- | --- | --- | --- | --- | --- | --- | --- |
|  | 4 | **PASO SUPERIOR TIPO MARCO** |  | 2024-08-29 | 2024-11-27 |  |  |  |  |  |
|  | 1 | **Obras de Concreto Simple** |  | 2024-08-29 | 2024-09-02 |  |  |  |  |  |
| A5470 |  | Encofrado y Desencofrado en Estructuras | 2d | 2024-08-29 | 2024-08-30 | A5600 SS+6d | 9d | 0d | HH [18 h] | 21,981.53 |
| A5730 |  | Concreto Clase F (F'C=100 KG/CM2) - Solados | 3d | 2024-08-31 | 2024-09-02 | A5470 | 9d | 0d | HH [27 h]; Concreto premezclado F'C=100 kg/cm2 con cemento T-I [39] | 1,959.17 |
|  | 2 | **Obras de Concreto Armado** |  | 2024-09-17 | 2024-11-27 |  |  |  |  |  |
| A5500 |  | Encofrado y Desencofrado Cara Oculta | 26d | 2024-09-17 | 2024-10-12 | A5520 SS | 11d | 0d | HH [234 h] | 44,135.96 |
| A5510 |  | Encofrado y Desencofrado Cara Vista | 37d | 2024-09-17 | 2024-10-23 | A5500 SS, A5500 FF | 11d | 2d | HH [333 h] | 62,339.55 |
| A5520 |  | Acero FY=4200 KG/CM2, Grado 60 | 22d | 2024-09-17 | 2024-10-08 | A5730 FS+14d | 9d | 0d | HH [198 h]; Acero Corrugado fy = 4200 kg/cm2 grado 60 [74165] | 362,948.16 |
| A5490 |  | Concreto Clase A(F'C=280 KG/CM2)- Premezclado - Cimentacion | 17d | 2024-10-09 | 2024-10-25 | A5520, A5500 SS, A5510 SS, A5500 FF, A5510 FF | 9d | 0d | HH [153 h]; Concreto premezclado F'C=280 kg/cm2 con cemento T-I [277.7]; arena gruesa [16]; Cemento Portlamd Tipo I [678] | 212,504.37 |
| A5480 |  | Concreto Clase A(F'C=280 KG/CM2)- Premezclado - muros | 24d | 2024-10-11 | 2024-11-03 | A5490 SS+2d | 9d | 0d | HH [216 h]; Concreto premezclado F'C=280 kg/cm2 con cemento T-I [311.44]; arena gruesa [18]; Cemento Portlamd Tipo I [761] | 240,736.89 |
| A5780 |  | Pintura Bituminosa | 16d | 2024-10-19 | 2024-11-03 | A5480 SS+8d | 9d | 0d | HH [144 h]; PINTURA ASFALTICA [728] | 22,944.32 |
| A5540 |  | Tubo PVC - D=6" | 4d | 2024-10-26 | 2024-10-29 | A5480 SS+15d | 12d | 0d | HH [36 h] | 1,175.41 |
| A5550 |  | Tubo PVC - D=4" | 2d | 2024-10-30 | 2024-10-31 | A5540 | 12d | 3d | HH [18 h] | 518.46 |
| A5560 |  | Baranda Metalica Tipica H=0.50M | 3d | 2024-11-04 | 2024-11-06 | A5480 SS+15d, A5780, A5550 | 9d | 0d | HH [27 h]; Baranda Metalica [37 m3] | 20,222.45 |
| A5740 |  | Concreto Clase A(F'C=280 KG/CM2)- Premezclado - losas | 15d | 2024-11-07 | 2024-11-21 | A5480, A5560 | 9d | 0d | HH [135 h]; Concreto premezclado F'C=280 kg/cm2 con cemento T-I [189.5]; arena gruesa [11]; Cemento Portlamd Tipo I [463] | 144,507.03 |
| A5530 |  | Geocompuesto de Drenaje | 4d | 2024-11-22 | 2024-11-25 | A5740, A5490 | 34d | 0d | HH [36 h]; Geocompuesto de Drenaje [122] | 5,882.06 |
| A5830 |  | Junta de dilatación con poliesterino expandido | 2d | 2024-11-26 | 2024-11-27 | A5530 | 34d |  | HH [18 h] |  |
|  | 5 | **PAVIMENTO RIGIDO** |  | 2024-12-05 | 2024-12-23 |  |  |  |  |  |
| A5340 |  | Subbase granular | 2d | 2024-12-05 | 2024-12-06 | A5740 SS+28d | 9d | 0d | HH [18 h] |  |
| A5650 |  | Acero FY=4200 KG/CM2, Grado 60 | 11d | 2024-12-07 | 2024-12-17 | A5340 | 9d | 0d | HH [99 h]; Acero Corrugado fy = 4200 kg/cm2 grado 60 [3744] | 34,084.81 |
| A5660 |  | Encofrado y Desencofrado de Pavimientos | 3d | 2024-12-07 | 2024-12-09 | A5340 | 22d |  | HH [27 h] | 6,384.89 |
| A5670 |  | Acero Longitudinal (Barra de amarre Ø1/2" Corrugado) | 5d | 2024-12-08 | 2024-12-12 | A5340 FS+1d | 14d | 5d | HH [45 h] | 4,314.26 |
| A5680 |  | Acero Transversal (Pasa Juntas Dowells Ø 1 1/4" Liso) | 4d | 2024-12-14 | 2024-12-17 | A5340 FS+2d, A5650 SS, A5650 FF, A5670 SS, A5670 FF | 9d | 0d | HH [36 h] | 20,880.18 |
| A5720 |  | Junta de Aislamiento | 3d | 2024-12-16 | 2024-12-18 | A5340 SS+2d, A5680 SS+2d, A5680 FF, A5340 FF | 13d | 4d | HH [27 h] | 2,169.3 |
| A5690 |  | Canastilla para Ø5/16" para Dowells | 6d | 2024-12-18 | 2024-12-23 | A5340 SS, A5680 SS+4d, A5680 FF, A5340 FF | 9d | 0d | HH [54 h]; Canastilla 5/16" para dowells [337] | 86,760.29 |
| A5710 |  | Junta Transversal de Contraccion | 4d | 2024-12-20 | 2024-12-23 | A5340 SS, A5680 SS, A5690 FF, A5680 FF, A5340 FF | 9d | 0d | HH [36 h] | 5,543.22 |
| A5640 |  | Pavimiento Hidraulico (F'C 300KG/CM2) | 1d | 2024-12-22 | 2024-12-22 | A5700 SS | 9d |  | HH [9 h] | 180,200.61 |
| A5700 |  | Concreto Clase A (F'C=280 KG/CM2)- Premezclado - Losas | 2d | 2024-12-22 | 2024-12-23 | A5720 FF+1d, A5710 SS, A5720 SS, A5710 FF | 9d | 0d | HH [18 h]; Concreto premezclado F'C=280 kg/cm2 con cemento T-I [2.67]; arena gruesa; Cemento Portlamd Tipo I [7] | 3,054.36 |

| ID | WBS | Activity | Type | Duration | Start | Finish | Predecessors | Total float | Free float | Resources | Cost |
| --- | --- | --- | --- | --- | --- | --- | --- | --- | --- | --- | --- |
|  | 9 | **TRANSPORTE 2024** |  |  | 2024-06-23 | 2024-12-31 |  |  |  |  |  |
| A6120 |  | Transporte de material excedente |  | 182d | 2024-06-23 | 2024-12-21 | A1590 SS | 206d | 201d | HH [1638 h] | 1,273,858.27 |
| A6110 |  | Transporte de material orgánico (a DMO) |  | 180d | 2024-06-25 | 2024-12-21 | A1570 SS | 206d | 201d | HH [1620 h] | 139,810.5 |
| A6130 |  | Transporte de material de prestamo (afirmado) |  | 151d | 2024-08-03 | 2024-12-31 | A3570 SS | 196d | 191d | HH [1359 h] | 224,568.56 |
| A6150 |  | Transporte de material de préstamo cantera de rio (cuerpo de terraplén) |  | 151d | 2024-08-03 | 2024-12-31 | A3570 SS | 196d | 191d | HH [1359 h] | 216,536.3 |
| A6140 |  | Transporte de roca |  | 138d | 2024-08-16 | 2024-12-31 | A3020 SS | 196d | 191d | HH [1242 h] | 586,614.96 |
|  | 2 | **TEMPORADA DE LLUVIAS** |  |  | 2025-01-01 | 2025-04-30 |  |  |  |  |  |
| A4660 |  | Temporada de lluvias |  | 120d | 2025-01-01 | 2025-04-30 | A6230, A6250, A6270, A6290, A6090 | 0d |  |  |  |
|  | 5 | **CONSTRUCCION DE QUEBRADAS 2025** |  |  | 2025-04-03 | 2025-07-15 |  |  |  |  |  |
| A6210 |  | Produccion de Roca |  | 89d | 2025-04-03 | 2025-06-30 | A4660 SS+92d | 5d | 0d |  |  |
| A6070 |  | Suministro de Roca 2025 |  | 56d | 2025-05-16 | 2025-07-10 | A6210 SS+43d | 5d | 2d | Roca [17730 m3] |  |
|  | 2 | **OBRAS PROVISIONALES 2025** |  |  | 2025-04-16 | 2025-07-15 |  |  |  |  |  |
| A5920 |  | Movilización de Maquinaria Pesada |  | 15d | 2025-04-16 | 2025-04-30 | A4660 SS+105d | 0d |  | HH [135 h] | 992,040 |
| A5940 |  | Trazo y Replanteo Inicial |  | 78d | 2025-04-24 | 2025-07-10 | A5920 SS+8d | 0d |  | HH [702 h] | 43,103.7 |
| A5950 |  | Desmovilización |  | 15d | 2025-07-01 | 2025-07-15 | A5940 SS+68d | 0d |  | HH [135 h] |  |
|  | 3 | **MANTENIMIENTO DE VIAS 2025** |  |  | 2025-04-24 | 2025-05-16 |  |  |  |  |  |
| A5880 |  | Mejoramiento y Habilitación de caminos de acceso |  | 23d | 2025-04-24 | 2025-05-16 | A4660 SS+100d, A5920 SS+8d | 60d | 0d | HH [207 h] | 278,414.02 |
| A5890 |  | Limpieza manual de material vegetal y de residuos |  | 5d | 2025-04-29 | 2025-05-03 | A5880 SS+5d | 73d | 68d | HH [45 h] | 10,579.8 |
|  | 1 | **QUEBRADA JACAYITA 2025** |  |  | 2025-05-01 | 2025-07-10 |  |  |  |  |  |
| A6300 |  | Inicio de Quebrada Jacayita | milestone | 0d | 2025-05-01 | 2025-05-01 | A4660 SS+120d | 5d | 0d |  |  |
| A6310 |  | Fin de Quebrada Jacayita | milestone | 0d | 2025-07-10 | 2025-07-10 | A5040 FF, A4790 FF, A4780 FF, A4810 FF, A4880 FF, A5810 FF, A4990 FF, A5090 FF, A5070 FF | 5d | 4d |  |  |
|  | 1 | **DEMOLICIONES** |  |  | 2025-05-01 | 2025-05-10 |  |  |  |  |  |
| A4680 |  | Demolicion de Baden |  | 3d | 2025-05-01 | 2025-05-03 | A6300 SS | 5d | 0d | HH [27 h] | 10,966.55 |
| A4690 |  | Demolicion de Pavimentos |  | 5d | 2025-05-04 | 2025-05-08 | A4680 | 5d | 0d | HH [45 h] | 8,430.62 |
| A4720 |  | Eliminacion de material de demolicion |  | 2d | 2025-05-09 | 2025-05-10 | A4690 | 5d | 0d | HH [18 h] | 4,149.11 |

| ID | WBS | Activity | Duration | Start | Finish | Predecessors | Total float | Free float | Resources | Cost |
| --- | --- | --- | --- | --- | --- | --- | --- | --- | --- | --- |
|  | 8 | **MOVIMIENTO DE TIERRAS** |  | 2025-05-09 | 2025-07-10 |  |  |  |  |  |
| A4730 |  | Desbroce | 2d | 2025-05-09 | 2025-05-10 | A4690 | 5d | 0d | HH [18 h]; EXCAVADORA CAT 336 [18 h] | 8,345.7 |
| A4740 |  | Excavación de cimentación | 52d | 2025-05-11 | 2025-07-01 | A4730 SS+2d, A4730 FF, A4720 | 5d | 0d | HH [468 h]; EXCAVADORA CAT 336 [468 h]; Excavación de cimentacion [27067] | 371,933.31 |
| A4750 |  | Perfilado y conformación de Plataforma de fundación | 7d | 2025-05-13 | 2025-05-19 | A4740 SS+2d | 5d | 0d | HH [63 h] | 30,981.78 |
| A4760 |  | Conformación de material excedente en DME | 34d | 2025-05-15 | 2025-06-17 | A4750 SS+2d | 5d | 0d | HH [306 h] | 129,697.33 |
| A4790 |  | Relleno Estructural | 35d | 2025-05-31 | 2025-07-04 | A4840 SS+11d | 11d | 6d | HH [315 h]; Relleno estructural [5721] | 558,134.75 |
| A4770 |  | Conformación de material excedente en DMO | 5d | 2025-06-13 | 2025-06-17 | A4760 SS+2d, A4760 FF | 5d | 0d | HH [45 h] | 13,735.59 |
| A4780 |  | Relleno con material granular (incluye extracción de material, zarandeo y combinación de material) | 2d | 2025-06-23 | 2025-06-24 | A4830 | 5d | 0d | HH [18 h] | 5,595.68 |
| A4810 |  | Colocación de Roca en Uña | 18d | 2025-06-23 | 2025-07-10 | A4830 | 5d | 0d | HH [162 h]; EXCAVADORA CAT 336 [162 h] | 77,516.02 |
|  | 6 | **ROCA RECEBADA** |  | 2025-05-18 | 2025-06-22 |  |  |  |  |  |
| A4830 |  | Roca Recebada | 36d | 2025-05-18 | 2025-06-22 | A4750 SS+5d, A4750 FF, A6070 SS | 5d | 0d | HH [324 h]; EXCAVADORA CAT 336 [324 h]; Colocación de roca recebada [4856] | 1,274,041.4 |
|  | 2 | **MURO DE CONTENCIÓN CICLOPEO - Obras de Concreto Simple** |  | 2025-05-18 | 2025-07-10 |  |  |  |  |  |
| A5030 |  | Concreto Clase F (F'C=100 KG/CM2) - Solados | 31d | 2025-05-18 | 2025-06-17 | A4830 SS | 5d | 0d | HH [279 h]; Concreto premezclado F'C=100 kg/cm2 con cemento T-I [408] | 229,429.39 |
| A4840 |  | Concreto Clase A (F'C=280 KG/CM2)-Premezclado - muros +30% PM DMAX=6" | 44d | 2025-05-20 | 2025-07-02 | A5030 SS+2d | 5d | 0d | HH [396 h]; Concreto premezclado F'C=280 kg/cm2 con cemento T-I [2657.09]; arena gruesa [135]; Cemento Portlamd Tipo I [5788] | 1,349,020.04 |
| A5050 |  | Encofrado y Desencofrado Cara Oculta | 45d | 2025-05-20 | 2025-07-03 | A4840 SS | 12d | 0d | HH [405 h] | 204,047.5 |
| A5060 |  | Encofrado y Desencofrado Cara Vista | 33d | 2025-06-01 | 2025-07-03 | A5050 SS, A5050 FF | 12d | 7d | HH [297 h] | 153,612.94 |
| A4850 |  | Concreto Clase A (F'C=280 KG/CM2)- Premezclado - muros+30% PM DMAX=4" | 3d | 2025-07-03 | 2025-07-05 | A4840 | 5d | 0d | HH [27 h]; Concreto premezclado F'C=280 kg/cm2 con cemento T-I [26.63]; arena gruesa [2]; Cemento Portlamd Tipo I [66] | 15,329.9 |
| A5040 |  | Concreto Clase A (F'C=280 KG/CM2)- Premezclado | 8d | 2025-07-03 | 2025-07-10 | A5060 FF, A5060 SS, A4850 SS | 5d | 0d | HH [72 h]; Concreto premezclado F'C=280 kg/cm2 con cemento T-I [286.75]; arena gruesa [16]; Cemento Portlamd Tipo I [700] | 210,032.91 |
|  | 3 | **MURO DE CONTENCIÓN CON RAPIDA - Obras de Concreto Armado** |  | 2025-05-13 | 2025-06-20 |  |  |  |  |  |
| A4880 |  | Encofrado y Desencofrado Cara Vista | 35d | 2025-05-13 | 2025-06-16 | A4870 FF | 29d | 24d | HH [315 h] | 169,890.73 |
| A4890 |  | Acero FY=4200 KG/CM2, Grado 60 | 24d | 2025-05-19 | 2025-06-11 | A4740 SS+8d | 26d | 0d | HH [216 h]; Acero Corrugado fy = 4200 kg/cm2 grado 60 [98361] | 559,224.68 |
| A4860 |  | Concreto Clase A (F'C=280 KG/CM2)- Premezclado - muros | 24d | 2025-05-21 | 2025-06-13 | A4890 SS+2d | 26d | 0d | HH [216 h]; Concreto premezclado F'C=280 kg/cm2 con cemento T-I [638.65]; arena gruesa [36]; Cemento Portlamd Tipo I [1560] | 493,663.68 |
| A4870 |  | Encofrado y Desencofrado Cara Oculta | 22d | 2025-05-26 | 2025-06-16 | A4860 SS+5d | 26d | 0d | HH [198 h] | 36,433.73 |
| A4910 |  | Tubo PVC - D=6" | 7d | 2025-05-31 | 2025-06-06 | A4870 SS+5d | 26d | 0d | HH [63 h] | 6,212.21 |
| A4920 |  | Tubo PVC - D=4" | 5d | 2025-06-07 | 2025-06-11 | A4910 | 26d | 0d | HH [45 h] | 4,290.72 |
| A4900 |  | Geocompuesto de Drenaje | 8d | 2025-06-12 | 2025-06-19 | A4920 | 26d | 0d | HH [72 h]; Geocompuesto de Drenaje [470] | 22,541.9 |
| A5810 |  | Junta de dilatacion | 0d | 2025-06-20 | 2025-06-20 | A4900 | 26d | 21d | HH |  |

| ID | WBS | Activity | Duration | Start | Finish | Predecessors | Total float | Free float | Resources | Cost |
| --- | --- | --- | --- | --- | --- | --- | --- | --- | --- | --- |
|  | 4 | **PASO SUPERIOR TIPO MARCO** |  | 2025-05-11 | 2025-06-19 |  |  |  |  |  |
|  | 1 | **Obras de Concreto Simple** |  | 2025-05-11 | 2025-05-14 |  |  |  |  |  |
| A4930 |  | Encofrado y Desencofrado en Estructuras | 2d | 2025-05-11 | 2025-05-12 | A4740 SS | 5d | 0d | HH [18 h] | 1,036.78 |
| A5160 |  | Concreto Clase F (F'C=100 KG/CM2) - Solados | 2d | 2025-05-13 | 2025-05-14 | A4930 | 5d | 0d | HH [18 h]; Concreto premezclado F'C=100 kg/cm2 con cemento T-I [21] | 11,889.8 |
|  | 2 | **Obras de Concreto Armado** |  | 2025-05-15 | 2025-06-19 |  |  |  |  |  |
| A4960 |  | Encofrado y Desencofrado Cara Oculta | 28d | 2025-05-15 | 2025-06-11 | A4980 FF+3d, A4980 SS | 32d | 0d | HH [252 h] | 21,689.22 |
| A4970 |  | Encofrado y Desencofrado Cara Vista | 28d | 2025-05-15 | 2025-06-11 | A4960 SS, A4960 FF | 32d | 0d | HH [252 h] | 51,942.8 |
| A4980 |  | Acero FY=4200 KG/CM2, Grado 60 | 14d | 2025-05-15 | 2025-05-28 | A5160 | 5d | 0d | HH [126 h]; Acero Corrugado fy = 4200 kg/cm2 grado 60 [37799] | 183,655.31 |
| A5170 |  | Concreto Clase A(F'C=280 KG/CM2)- Premezclado - losas | 9d | 2025-05-25 | 2025-06-02 | A4980 FF+5d, A4980 SS | 5d | 0d | HH [81 h]; Concreto premezclado F'C=280 kg/cm2 con cemento T-I [111.17]; arena gruesa [6]; Cemento Portlamd Tipo I [272] | 86,715.94 |
| A4940 |  | Concreto Clase A(F'C=280 KG/CM2)- Premezclado - muros | 12d | 2025-05-30 | 2025-06-10 | A5170 SS+5d, A5170 FF | 26d | 0d | HH [108 h]; Concreto premezclado F'C=280 kg/cm2 con cemento T-I [160]; arena gruesa [9]; Cemento Portlamd Tipo I [391] | 123,699.99 |
| A4950 |  | Concreto Clase A(F'C=280 KG/CM2)- Premezclado - Cimentacion | 13d | 2025-05-30 | 2025-06-11 | A4940 SS, A4970 FF | 32d | 6d | HH [117 h]; Concreto premezclado F'C=280 kg/cm2 con cemento T-I [160]; arena gruesa [9]; Cemento Portlamd Tipo I [404] | 126,592 |
| A5000 |  | Tubo PVC - D=6" | 2d | 2025-06-04 | 2025-06-05 | A4940 SS+5d | 36d | 0d | HH [18 h] | 698.28 |
| A5180 |  | Pintura Bituminosa | 8d | 2025-06-04 | 2025-06-11 | A4940 SS+5d | 34d | 2d | HH [360 h]; PINTURA ASFALTICA [72] | 11,349.9 |
| A5010 |  | Tubo PVC - D=4" | 2d | 2025-06-06 | 2025-06-07 | A5000, A5180 SS | 36d | 10d | HH [18 h] | 429.07 |
| A5020 |  | Baranda Metalica Tipica H=0.50M | 2d | 2025-06-16 | 2025-06-17 | A4940 FS+5d | 26d | 0d | HH [18 h]; Baranda Metalica [18 m3] | 10,079.06 |
| A4990 |  | Geocompuesto de Drenaje | 2d | 2025-06-18 | 2025-06-19 | A5170, A4950, A5010, A5020 | 26d | 21d | HH [18 h]; Geocompuesto de Drenaje [48] | 2,318.35 |
|  | 5 | **PAVIMENTO RIGIDO** |  | 2025-06-19 | 2025-07-10 |  |  |  |  |  |
| A4820 |  | Subbase granular | 2d | 2025-06-19 | 2025-06-20 | A5170 SS+25d | 5d | 0d | HH [18 h] |  |
| A5080 |  | Acero FY=4200 KG/CM2, Grado 60 | 6d | 2025-06-21 | 2025-06-26 | A4820 | 19d | 9d | HH [54 h]; Acero Corrugado fy = 4200 kg/cm2 grado 60 [1989] | 9,623.08 |
| A5100 |  | Acero Longitudinal (Barra de amarre Ø1/2" Corrugado) | 12d | 2025-06-22 | 2025-07-03 | A4820 FS+1d | 12d | 2d | HH [108 h] | 1,570.73 |
| A5110 |  | Acero Transversal (Pasa Juntas Dowells Ø 1 1/4" Liso) | 13d | 2025-06-23 | 2025-07-05 | A4820 FS+2d | 5d | 0d | HH [117 h] | 9,967.88 |
| A5120 |  | Canastilla para Ø5/16" para Dowells | 7d | 2025-06-29 | 2025-07-05 | A4820 SS, A5110 SS+4d, A5110 FF, A4820 FF | 5d | 0d | HH [63 h]; Canastilla 5/16" para dowells [275] | 32,507.72 |
| A5140 |  | Junta Transversal de Contraccion | 8d | 2025-06-29 | 2025-07-06 | A4820 SS, A5110 SS, A5120 SS, A5120 FF, A5110 FF, A4820 FF | 5d | 0d | HH [72 h] | 1,770.57 |
| A5090 |  | Encofrado y Desencofrado de Pavimientos | 2d | 2025-07-04 | 2025-07-05 | A5110 FF, A5080 FF, A5100 FF | 10d | 5d | HH [18 h] | 2,295.76 |
| A5150 |  | Junta de Aislamiento | 2d | 2025-07-04 | 2025-07-05 | A4820 SS+2d, A5110 SS+2d, A5110 FF, A4820 FF | 7d | 2d | HH [18 h] | 1,174.31 |
| A5130 |  | Concreto Clase A (F'C=280 KG/CM2)- Premezclado - Losas | 2d | 2025-07-07 | 2025-07-08 | A5150 FF+1d, A5140, A5150 SS | 5d | 0d | HH [18 h]; Concreto premezclado F'C=280 kg/cm2 con cemento T-I [2.16]; arena gruesa; Cemento Portlamd Tipo I [5] | 1,582.11 |
| A5070 |  | Pavimiento Hidraulico (F'C 300KG/CM2) | 2d | 2025-07-09 | 2025-07-10 | A5130 | 5d | 0d | HH [18 h] | 67,839.14 |

| ID | WBS | Activity | Type | Duration | Start | Finish | Predecessors | Total float | Free float | Resources | Cost |
| --- | --- | --- | --- | --- | --- | --- | --- | --- | --- | --- | --- |
|  | 4 | **QUEBRADA SAN JERONIMO 2025** |  |  | 2025-05-11 | 2025-07-10 |  |  |  |  |  |
| A6320 |  | Inicio de Quebrada San Jeronimo | milestone | 0d | 2025-05-11 | 2025-05-11 | A4660 FS+10d | 5d | 0d |  |  |
| A6330 |  | Fin de Quebrada San Jeronimo | milestone | 0d | 2025-07-10 | 2025-07-10 | A1830 FF, A1860 FF | 5d | 4d |  |  |
|  | 1 | **DEMOLICIONES** |  |  | 2025-05-11 | 2025-06-14 |  |  |  |  |  |
| A1690 |  | Demolicion de Canales en Quebradas |  | 28d | 2025-05-11 | 2025-06-07 | A6320 SS | 5d | 0d | HH [252 h] | 84,771.4 |
| A1750 |  | Demolicion de Cerco Perimétrico |  | 9d | 2025-05-16 | 2025-05-24 | A1690 SS+5d | 5d | 0d | HH [81 h] | 23,933.28 |
| A1760 |  | Eliminacion de material de demolicion |  | 15d | 2025-05-31 | 2025-06-14 | A1750 SS+15d, A1750 FF | 31d | 26d | HH [135 h] | 33,499.6 |
|  | 8 | **MOVIMIENTO DE TIERRAS** |  |  | 2025-05-25 | 2025-07-10 |  |  |  |  |  |
| A1780 |  | Desbroce |  | 2d | 2025-05-25 | 2025-05-26 | A1750 | 5d | 0d | HH [18 h]; EXCAVADORA CAT 336 [18 h] | 16,314.9 |
| A1790 |  | Excavación de cimentación |  | 30d | 2025-05-27 | 2025-06-25 | A1780 | 5d | 0d | HH [270 h]; EXCAVADORA CAT 336 [270 h]; Excavación de cimentacion [29173] | 802,937.21 |
| A1840 |  | Relleno Estructural |  | 30d | 2025-06-05 | 2025-07-04 | A1790 SS+9d | 5d | 0d | HH [270 h]; Relleno estructural [7469] | 1,908,574.23 |
| A1810 |  | Conformación de material excedente en DME |  | 33d | 2025-06-08 | 2025-07-10 | A1690 | 5d | 0d | HH [297 h] | 282,808.47 |
| A1800 |  | Perfilado y conformación de Plataforma de fundación |  | 11d | 2025-06-15 | 2025-06-25 | A1790 SS+3d, A1790 FF | 18d | 13d | HH [99 h] | 62,425.71 |
| A1860 |  | Colocación de Roca en Uña |  | 5d | 2025-07-06 | 2025-07-10 | A1900 | 5d | 0d | HH [45 h]; EXCAVADORA CAT 336 [45 h] | 25,461.96 |
| A1820 |  | Conformación de material excedente en DMO |  | 4d | 2025-07-07 | 2025-07-10 | A1810 SS+2d, A1810 FF | 5d | 0d | HH [36 h] | 26,931.29 |
| A1830 |  | Relleno con material granular (incluye extracción de material, zarandeo y combinación de material) |  | 2d | 2025-07-09 | 2025-07-10 | A1820 SS+2d, A1820 FF, A1800 | 5d | 0d | HH [18 h] | 8,109.5 |
|  | 6 | **ROCA RECEBADA** |  |  | 2025-06-06 | 2025-07-05 |  |  |  |  |  |
| A1900 |  | Roca Recebada |  | 30d | 2025-06-06 | 2025-07-05 | A1790 SS+10d, A6070 SS | 5d | 0d | HH [270 h]; EXCAVADORA CAT 336 [270 h]; Colocación de roca recebada [3355] | 1,820,435.73 |
|  | 5 | **TRANSPORTE 2025** |  |  | 2025-05-09 | 2025-07-10 |  |  |  |  |  |
| A5980 |  | Transporte de material excedente |  | 63d | 2025-05-09 | 2025-07-10 | A4720 SS | 5d |  | HH [567 h] | 1,273,858.27 |
| A6020 |  | Transporte de roca |  | 54d | 2025-05-18 | 2025-07-10 | A4830 SS | 5d | 0d | HH [486 h] | 586,614.96 |
| A6000 |  | Transporte de material de prestamo (afirmado) |  | 36d | 2025-06-05 | 2025-07-10 | A1840 SS | 5d | 0d | HH [324 h] | 224,568.56 |
| A5960 |  | Transporte de material orgánico (a DMO) |  | 28d | 2025-06-13 | 2025-07-10 | A4770 SS | 5d | 0d | HH [252 h] | 139,810.5 |
| A6040 |  | Transporte de material de préstamo cantera de rio (cuerpo de terraplén) |  | 18d | 2025-06-23 | 2025-07-10 | A4780 SS | 5d | 0d | HH [162 h] | 216,536.3 |

| ID | WBS | Activity | Duration | Start | Finish | Predecessors | Total float | Free float | Resources | Cost |
| --- | --- | --- | --- | --- | --- | --- | --- | --- | --- | --- |
|  | 3 | **SEÑALIZACION VIAL** |  | 2024-06-21 | 2025-07-10 |  |  |  |  |  |
| A2760 |  | Señalización Horizontal | 385d | 2024-06-21 | 2025-07-10 | A2680 SS | 5d | 0d | HH [3465 h] |  |
| A2770 |  | Seguridad Vial | 385d | 2024-06-21 | 2025-07-10 | A2680 SS | 5d | 0d | HH [3465 h] |  |
| A2730 |  | Señalización Vertical | 380d | 2024-06-26 | 2025-07-10 | A2680 SS+5d | 5d | 0d | HH [3420 h] | 73,667.47 |
|  | 6 | **CALIDAD** |  | 2024-07-15 | 2025-07-10 |  |  |  |  |  |
| A6080 |  | Control de Calidad | 361d | 2024-07-15 | 2025-07-10 | A2690 SS, A2700 SS, A2710 SS, A2720 SS | 5d | 0d | HH [3249 h] |  |
|  | 8 | **SOLUCION DE INTERFERENCIAS** |  | 2024-07-01 | 2025-07-10 |  |  |  |  |  |
| A6090 |  | Solucion de interferencias 2024 | 180d | 2024-07-01 | 2024-12-27 | A2680 SS+10d | 4d |  | HH [1620 h]; valvula compuerta elastomerica [7]; Compuerta plana tipo tarjeta [18]; Suministro de Compuerta plana tipo tarjeta 1.00 x 1.00m [10]; Tubería HDPE Corrugado 630 mm [891]; Tuberia HDPE NTP ISO 4427 PE-100 SDR 21 [1265] |  |
| A6100 |  | Solucion de interferencias 2025 | 91d | 2025-04-11 | 2025-07-10 | A4660 SS+100d | 5d | 0d | HH [819 h]; Suministro de Compuerta plana tipo tarjeta 1.00 x 1.00m [3]; Compuerta plana tipo tarjeta [7]; valvula compuerta elastomerica [5]; Tubería HDPE Corrugado 630 mm [383]; Tuberia HDPE NTP ISO 4427 PE-100 SDR 21 [542] |  |
|  | 7 | **INFRAESTRUCTURA VERDE Y PAISAJISMO** |  | 2024-08-14 | 2025-07-10 |  |  |  |  |  |
| A2740 |  | Instalaciones de Paisajismo e Infraestructura Verde | 331d | 2024-08-14 | 2025-07-10 | A4220 SS | 5d | 4d | HH [2979 h] | 2,994,951.07 |
|  | 1 | **FIN DE OBRAS** |  | 2025-07-11 | 2025-07-11 |  |  |  |  |  |
| A2780 |  | Fin de Obras | 0d | 2025-07-11 | 2025-07-11 | A1760, A2840, A3310, A4510 SS, A2730, A3110 SS, A6080, A5890, A2770, A2760, A6100, A6090, A6040, A6020, A6000, A5960, A6120, A6110, A6130, A6150, A6140 | 5d | 4d |  |  |
